# Strategic Plan

How a schedule from MS Project changed from version to version. A marks actual dates.

## Version 1 (data date 2009-03-08, saved 2009-03-08, file periodicals.mpp)

| ID | WBS | Task | Duration | Start | Finish | Predecessors | Total float | Constraint |
| --- | --- | --- | --- | --- | --- | --- | --- | --- |
| 1 | 1 | **Self-Assessment** | 8d | 2005-08-01 | 2005-08-10 |  | 0d |  |
| 2 |  | Define business vision | 1d | 2005-08-01 | 2005-08-01 |  | 0d |  |
| 3 |  | Identify available skills, information and support | 2d | 2005-08-02 | 2005-08-09 | 2 | 0d |  |
| 4 |  | Decide whether to proceed | 1d | 2005-08-10 | 2005-08-10 | 3 | 0d | start no earlier than 2005-08-08 |
| 5 | 2 | **Define the Opportunity** | 10d | 2005-08-11 | 2005-08-24 |  | 0d |  |
| 6 |  | Research the market and competition | 1d | 2005-08-11 | 2005-08-11 | 4 | 0d | start no earlier than 2005-08-08 |
| 7 |  | Interview owners of similar businesses | 5d | 2005-08-12 | 2005-08-18 | 6 | 0d | start no earlier than 2005-08-08 |
| 8 |  | Identify needed resources | 2d | 2005-08-19 | 2005-08-22 | 7 | 0d |  |
| 9 |  | Identify operating cost elements | 2d | 2005-08-23 | 2005-08-24 | 8 | 0d |  |
| 10 | 3 | **Evaluate Business Approach** | 4d | 2005-08-25 | 2005-08-30 |  | 0d |  |
| 11 |  | Define new entity requirements | 1d | 2005-08-25 | 2005-08-25 | 9 | 0d |  |
| 12 |  | Identify on-going business purchase opportunities | 1d | 2005-08-26 | 2005-08-26 | 11 | 0d |  |
| 13 |  | Research franchise possibilities | 1d | 2005-08-29 | 2005-08-29 | 12 | 0d |  |
| 14 |  | Summarize business approach | 1d | 2005-08-30 | 2005-08-30 | 13 | 0d |  |
| 15 | 4 | **Evaluate Potential Risks and Rewards** | 9d | 2005-08-26 | 2005-09-08 |  | 0d |  |
| 16 |  | Assess market size and stability | 2d | 2005-08-26 | 2005-08-29 | 11 | 3d |  |
| 17 |  | Estimate the competition | 1d | 2005-08-30 | 2005-08-30 | 16 | 3d |  |
| 18 |  | Assess needed resource availability | 2d | 2005-08-31 | 2005-09-01 | 17 | 3d |  |
| 19 |  | Evaluate realistic initial market share | 1d | 2005-09-02 | 2005-09-02 | 18 | 3d |  |
| 20 |  | Determine financial requirements | 2d | 2005-08-31 | 2005-09-01 | 14 | 0d |  |
| 21 |  | Review personal suitability | 1d | 2005-09-02 | 2005-09-02 | 20 | 0d |  |
| 22 |  | Evaluate initial profitability | 1d | 2005-09-06 | 2005-09-06 | 21 | 0d |  |
| 23 |  | Review and modify the strategic plan | 2d | 2005-09-07 | 2005-09-08 | 22 | 0d |  |
| 24 |  | Confirm decision to proceed | 0d | 2005-09-08 | 2005-09-08 | 23 | 0d |  |

## Version 2 (saved 2009-03-08, file strategicplan.mpp)

Last finish 2005-09-08 → 2009-04-15 (+1315d).

Added:

| ID | Task | Duration | Start | Finish |
| --- | --- | --- | --- | --- |
| 1 | **Strategic Plan** | 28d | 2009-03-09 | 2009-04-15 |

Changed:

| ID | Task | Start | Finish |
| --- | --- | --- | --- |
| 2 | **Self-Assessment** | 2005-08-01 → 2009-03-09 (+1316d) | 2005-08-10 → 2009-03-18 (+1316d) |
| 3 | Define business vision | 2005-08-01 → 2009-03-09 (+1316d) | 2005-08-01 → 2009-03-09 (+1316d) |
| 4 | Identify available skills, information and support | 2005-08-02 → 2009-03-10 (+1316d) | 2005-08-09 → 2009-03-17 (+1316d) |
| 5 | Decide whether to proceed | 2005-08-10 → 2009-03-18 (+1316d) | 2005-08-10 → 2009-03-18 (+1316d) |
| 6 | **Define the Opportunity** | 2005-08-11 → 2009-03-19 (+1316d) | 2005-08-24 → 2009-04-01 (+1316d) |
| 7 | Research the market and competition | 2005-08-11 → 2009-03-19 (+1316d) | 2005-08-11 → 2009-03-19 (+1316d) |
| 8 | Interview owners of similar businesses | 2005-08-12 → 2009-03-20 (+1316d) | 2005-08-18 → 2009-03-26 (+1316d) |
| 9 | Identify needed resources | 2005-08-19 → 2009-03-27 (+1316d) | 2005-08-22 → 2009-03-30 (+1316d) |
| 10 | Identify operating cost elements | 2005-08-23 → 2009-03-31 (+1316d) | 2005-08-24 → 2009-04-01 (+1316d) |
| 11 | **Evaluate Business Approach** | 2005-08-25 → 2009-04-02 (+1316d) | 2005-08-30 → 2009-04-07 (+1316d) |
| 12 | Define new entity requirements | 2005-08-25 → 2009-04-02 (+1316d) | 2005-08-25 → 2009-04-02 (+1316d) |
| 13 | Identify on-going business purchase opportunities | 2005-08-26 → 2009-04-03 (+1316d) | 2005-08-26 → 2009-04-03 (+1316d) |
| 14 | Research franchise possibilities | 2005-08-29 → 2009-04-06 (+1316d) | 2005-08-29 → 2009-04-06 (+1316d) |
| 15 | Summarize business approach | 2005-08-30 → 2009-04-07 (+1316d) | 2005-08-30 → 2009-04-07 (+1316d) |
| 16 | **Evaluate Potential Risks and Rewards** | 2005-08-26 → 2009-04-03 (+1316d) | 2005-09-08 → 2009-04-15 (+1315d) |
| 17 | Assess market size and stability | 2005-08-26 → 2009-04-03 (+1316d) | 2005-08-29 → 2009-04-06 (+1316d) |
| 18 | Estimate the competition | 2005-08-30 → 2009-04-07 (+1316d) | 2005-08-30 → 2009-04-07 (+1316d) |
| 19 | Assess needed resource availability | 2005-08-31 → 2009-04-08 (+1316d) | 2005-09-01 → 2009-04-09 (+1316d) |
| 20 | Evaluate realistic initial market share | 2005-09-02 → 2009-04-10 (+1316d) | 2005-09-02 → 2009-04-10 (+1316d) |
| 21 | Determine financial requirements | 2005-08-31 → 2009-04-08 (+1316d) | 2005-09-01 → 2009-04-09 (+1316d) |
| 22 | Review personal suitability | 2005-09-02 → 2009-04-10 (+1316d) | 2005-09-02 → 2009-04-10 (+1316d) |
| 23 | Evaluate initial profitability | 2005-09-06 → 2009-04-13 (+1315d) | 2005-09-06 → 2009-04-13 (+1315d) |
| 24 | Review and modify the strategic plan | 2005-09-07 → 2009-04-14 (+1315d) | 2005-09-08 → 2009-04-15 (+1315d) |
| 25 | Confirm decision to proceed | 2005-09-08 → 2009-04-15 (+1315d) | 2005-09-08 → 2009-04-15 (+1315d) |
